# Aszfaltozás7

Schedule from MS Project, 2008-06-30 to 2008-07-18.

## Calendars

- Szabványos: Mon-Fri 08:00-12:00, 13:00-17:00; Sat-Sun off.

## Schedule

| ID | WBS | Task | Type | Duration | Start | Finish | Predecessors | Total slack |
| --- | --- | --- | --- | --- | --- | --- | --- | --- |
| 1 | RNV2007RF | **Rákóczi Ferenc utca** |  | 3d | 2008-06-30 | 2008-07-02 |  | 0d |
| 2 | RNV2007RF.ULZ | Az útszakasz lezárása | milestone | 0d | 2008-06-30 | 2008-06-30 |  | 0d |
| 3 | RNV2007RF.USK | Útszegély kijavítása |  | 1d | 2008-06-30 | 2008-06-30 | 2 | 1d |
| 4 | RNV2007RF.RBE | Régi útburkolat előkészítése |  | 2d | 2008-06-30 | 2008-07-01 | 2 | 0d |
| 5 | RNV2007RF.ASF | Aszfaltozás |  | 1d | 2008-07-02 | 2008-07-02 | 3, 4 | 0d |
| 6 | RNV2007RF.UAT | Az útszakasz átadása a forgalomnak | milestone | 0d | 2008-07-02 | 2008-07-02 | 5 | 0d |
| 7 | RNV2007KL | **Kossuth Lajos utca** |  | 12d | 2008-07-03 | 2008-07-18 |  | 0d |
| 8 | RNV2007KL.KUT | Kerülőút kitáblázása |  | 1d | 2008-07-03 | 2008-07-03 | 6 | 0d |
| 9 | RNV2007KL.ULZ | Az útszakasz lezárása | milestone | 0d | 2008-07-03 | 2008-07-03 | 8 | 0d |
| 10 | RNV2007KL.USK | Útszegély kijavítása |  | 2d | 2008-07-04 | 2008-07-07 | 9 | 2d |
| 11 | RNV2007KL.RBE | Régi útburkolat előkészítése |  | 4d | 2008-07-04 | 2008-07-09 | 9 | 0d |
| 12 | RNV2007KL.ASF | Aszfaltozás |  | 6d | 2008-07-10 | 2008-07-17 | 10, 11 | 0d |
| 13 | RNV2007KL.USE | Az útszakasz elkészült | milestone | 0d | 2008-07-17 | 2008-07-17 | 12 | 0d |
| 14 | RNV2007KL.TBS | A táblák beszedése |  | 1d | 2008-07-18 | 2008-07-18 | 13 | 0d |
| 15 | RNV2007KL.UAT | Az útszakasz átadása a forgalomnak | milestone | 0d | 2008-07-18 | 2008-07-18 | 14 | 0d |
